# Target Hall Scheduled Activities Sep 09 to Dec 30

Schedule from MS Project, 2015-09-09 to 2015-12-07, A marks actual dates.

## Calendars

- Standard: Mon-Fri 08:00-12:00, 13:00-17:00; Sat-Sun off.

## Resources

| Resource |
| --- |
| D.Wang |
| T.Cave |
| D.McDonald |
| A.Mjos |
| W.Paley |
| M.Dalla Valle |
| G.Minor |
| D.Jackson |
| RPG |
| I. Earle |
| ISAC Operator |
| C.Fisher |
| A. Laxdal |

## Schedule

| ID | WBS | Task | Duration | Start | Finish | Predecessors | Complete | Constraint | Resources | Work | Actual work |
| --- | --- | --- | --- | --- | --- | --- | --- | --- | --- | --- | --- |
| 1 | 1 | **TM1 Window Leak Investigation and Repairing -Stage 1** | 5.5d | 2015-09-09 08:00 A | 2015-09-16 12:00 A |  | 100% |  |  | 88h | 88h |
| 2 | 1.1 | Module Move -TM1- Silo to SHC | 1d | 2015-09-09 08:00 A | 2015-09-09 17:00 A |  | 100% | start no earlier than 2015-09-09 08:00 | D.Wang; T.Cave | 16h | 16h |
| 3 | 1.2 | TM1 Window Leak Investigation | 2d | 2015-09-10 08:00 A | 2015-09-11 17:00 A | 2 | 100% | start no earlier than 2015-09-10 08:00 | C.Fisher; D.Wang; G.Minor; A.Mjos | 64h | 64h |
| 4 | 1.3 | Module Move- TM1- SHC to Silo | 0.5d | 2015-09-16 08:00 A | 2015-09-16 12:00 A |  | 100% | start no earlier than 2015-09-16 08:00 | T.Cave; D.Wang | 8h | 8h |
| 5 | 2 | **TM4 with HpTa Ready for Beam in ITE** | 12d | 2015-09-21 08:00 A | 2015-10-06 17:00 A |  | 100% |  |  | 134h | 134h |
| 6 | 2.1 | Cameras Set up/Module Disconnect -TM4 in ITE | 0.25d | 2015-09-21 08:00 A | 2015-09-21 10:00 A |  | 100% | start no earlier than 2015-09-21 08:00 | T.Cave; D.Wang; D.McDonald | 6h | 6h |
| 7 | 2.2 | HpTa Target Insert into SHC | 0.25d | 2015-09-21 10:00 A | 2015-09-21 12:00 A | 6 | 100% | start no earlier than 2015-09-21 08:00 | A.Mjos; C.Fisher | 4h | 4h |
| 8 | 2.3 | Module Move -TM4- ITE to SHC | 0.25d | 2015-09-21 13:00 A | 2015-09-21 15:00 A | 7 | 100% | start no earlier than 2015-09-21 08:00 | D.Wang; T.Cave | 4h | 4h |
| 9 | 2.4 | HpTa Target Installation/Leak, Electrical Check | 0.25d | 2015-09-21 15:00 A | 2015-09-21 17:00 A | 8 | 100% | start no earlier than 2015-09-21 08:00 | C.Fisher; D.Wang; T.Cave | 6h | 6h |
| 10 | 2.5 | Module Move-TM4- SHC to CS | 0.5d | 2015-09-22 08:00 A | 2015-09-22 12:00 A | 9 | 100% | start no earlier than 2015-09-22 08:00 | T.Cave; D.Wang | 8h | 8h |
| 11 | 2.6 | Module Connect- TM4 at CS/ Start of CS Pumps | 0.5d | 2015-09-22 13:00 A | 2015-09-22 17:00 A | 10 | 100% | start no earlier than 2015-09-22 08:00 | D.Wang; D.McDonald | 8h | 8h |
| 12 | 2.7 | Spent Target Move-Ucx- SHC to storage Vault | 0.5d | 2015-09-23 08:00 A | 2015-09-23 12:00 A | 11 | 100% | start no earlier than 2015-09-23 08:00 | C.Fisher; D.Wang; T.Cave | 12h | 12h |
| 13 | 2.8 | Helium Pressure Test/ TM4 Conditioning at CS | 3.5d | 2015-09-23 13:00 A | 2015-09-28 17:00 A | 11 | 100% | finish no earlier than 2015-09-28 17:00 | D.Wang; A.Mjos | 56h | 56h |
| 14 | 2.9 | Module Disconnect-TM4 at CS/Venting | 0.25d | 2015-09-29 08:00 A | 2015-09-29 10:00 A | 13 | 100% | start no earlier than 2015-09-29 08:00 | D.Wang | 2h | 2h |
| 15 | 2.10 | Module Move -TM4- CS to ITE | 0.25d | 2015-09-29 10:00 A | 2015-09-29 12:00 A | 14 | 100% | start no earlier than 2015-09-29 08:00 | T.Cave; D.Wang | 4h | 4h |
| 16 | 2.11 | Module Connect- TM4 in ITE/Start of Pumps | 0.5d | 2015-09-29 13:00 A | 2015-09-29 17:00 A | 15 | 100% | start no earlier than 2015-09-29 08:00 | D.McDonald; D.Wang | 8h | 8h |
| 17 | 2.12 | Shielding Blocks Transfer -ITW to ITE | 1d | 2015-10-06 08:00 A | 2015-10-06 17:00 A | 16 | 100% | start no earlier than 2015-10-06 08:00 | D.McDonald; D.Wang | 16h | 16h |
| 18 | 3 | **TM2 with HpSiC Ready for Beam in ITW** | 23d | 2015-10-14 08:00 A | 2015-11-13 17:00 A |  | 100% |  |  | 72h | 72h |
| 19 | 3.1 | Cameras Set up/Module Disconnect-TM2 in ITW | 0.25d | 2015-10-14 08:00 A | 2015-10-14 10:00 A | 17 | 100% | start no earlier than 2015-10-14 08:00 | D.Wang; W.Paley; D.McDonald | 6h | 6h |
| 20 | 3.2 | HpSiC Target Insert into SHC | 0.25d | 2015-10-14 10:00 A | 2015-10-14 12:00 A | 19 | 100% | start no earlier than 2015-10-13 08:00 | A.Mjos; C.Fisher | 4h | 4h |
| 21 | 3.3 | Module Move-TM2- ITW to SHC | 0.25d | 2015-10-14 13:00 A | 2015-10-14 15:00 A | 20 | 100% | start no earlier than 2015-10-13 08:00 | D.Wang; W.Paley | 4h | 4h |
| 22 | 3.4 | Hp SiC Target Installation/Leak, Electrical Check | 0.25d | 2015-10-14 15:00 A | 2015-10-14 17:00 A | 21 | 100% | start no earlier than 2015-10-13 08:00 | D.Wang; C.Fisher; D.McDonald | 6h | 6h |
| 23 | 3.5 | New Anode Cable installation on TM2 Source Tray | 0.5d | 2015-10-15 08:00 A | 2015-10-15 12:00 A | 22 | 100% | start no earlier than 2015-10-14 08:00 | C.Fisher; A.Mjos | 8h | 8h |
| 24 | 3.6 | Module Move -TM2- SHC to ITW | 0.25d | 2015-10-20 08:00 A | 2015-10-20 10:00 A |  | 100% | start no earlier than 2015-10-20 08:00 | D.McDonald; T.Cave | 4h | 4h |
| 25 | 3.7 | Module Connect -TM2 in ITW / Start of Turbo Pumps | 0.5d | 2015-10-20 10:00 A | 2015-10-20 15:00 A | 24 | 100% | start no earlier than 2015-10-20 08:00 | D.McDonald; A.Mjos | 8h | 8h |
| 26 | 3.8 | Spent Target Move -ZrC#7 -SHC to Storage Vault | 1d | 2015-10-21 08:00 A | 2015-10-21 17:00 A | 24 | 100% | start no earlier than 2015-10-21 08:00 | C.Fisher; T.Cave | 16h | 16h |
| 27 | 3.9 | Shielding Blocks transfer - ITE to ITW | 1d | 2015-11-13 08:00 A | 2015-11-13 17:00 A | 25 | 100% | start no earlier than 2015-11-12 08:00 | M.Dalla Valle; W.Paley | 16h | 16h |

Notes:
- 27: Miaco will do this job with Bill. A procedure is made for him.

| ID | WBS | Task | Duration | Start | Finish | Predecessors | Complete | Remaining | Total slack | Free slack | Constraint | Resources | Work | Actual work |
| --- | --- | --- | --- | --- | --- | --- | --- | --- | --- | --- | --- | --- | --- | --- |
| 28 | 4 | **TM4 with UCx Ready for Beam in ITE** | 10d | 2015-11-24 08:00 | 2015-12-07 17:00 |  |  |  | 0d |  |  |  | 88.4h |  |
| 29 | 4.1 | Cameras Set up/Module Disconnect -TM4 in ITE | 0.2d | 2015-11-24 08:00 | 2015-11-24 09:36 | 27 |  |  | 3d | 0d | start no earlier than 2015-11-24 08:00 | T.Cave; D.Wang | 3.2h |  |
| 30 | 4.2 | LpUCx Target Insert into SHC | 0.2d | 2015-11-24 09:36 | 2015-11-24 11:12 | 29 |  |  | 3d | 0d | start no earlier than 2015-11-24 08:00 | A.Mjos; C.Fisher | 3.2h |  |
| 31 | 4.3 | Module Move -TM4-ITE to SHC | 0.2d | 2015-11-24 11:12 | 2015-11-24 13:48 | 30 |  |  | 3d | 0d | start no earlier than 2015-11-24 08:00 | D.Wang | 1.6h |  |
| 32 | 4.4 | LpUCx Target Installation/Leak, Electrical Check | 0.2d | 2015-11-24 13:48 | 2015-11-24 15:24 | 31 |  |  | 3d | 0d | start no earlier than 2015-11-24 08:00 | D.Wang; T.Cave | 3.2h |  |
| 33 | 4.5 | Module Move-TM4- SHC to CS/ Start of Pumps | 0.2d | 2015-11-24 15:24 | 2015-11-24 17:00 | 32 |  |  | 3d | 0d | start no earlier than 2015-11-24 08:00 | D.Wang; T.Cave | 3.2h |  |
| 34 | 4.6 | Helium Pressure Test/Module Connect-TM4 at CS | 0.5d | 2015-11-25 08:00 | 2015-11-25 12:00 | 33 |  |  | 3d | 0d | start no earlier than 2015-11-25 08:00 | D.Wang | 4h |  |
| 35 | 4.7 | TM4 Conditioning at CS | 3.5d | 2015-11-25 13:00 | 2015-11-30 17:00 | 34 |  |  | 3d | 0d |  | A.Mjos | 28h |  |
| 36 | 4.8 | Spent Target Move- HpTa- SHC to Storage Vault | 1d | 2015-11-26 08:00 | 2015-11-26 17:00 | 33 |  |  | 7d |  | start no earlier than 2015-11-26 08:00 | C.Fisher; D.Wang; T.Cave | 24h |  |
| 37 | 4.9 | Module Disconnect- TM4 at CS/ Argon Venting CS | 0.25d | 2015-12-01 08:00 | 2015-12-01 10:00 | 35 |  |  | 3d | 0d | start no earlier than 2015-12-01 08:00 | D.Wang | 2h |  |
| 38 | 4.10 | Module Move -TM4- CS to ITE | 0.25d | 2015-12-01 10:00 | 2015-12-01 12:00 | 37 |  |  | 3d | 0d | start no earlier than 2015-12-01 08:00 | D.Wang; T.Cave | 4h |  |
| 39 | 4.11 | Module Connect -TM4 in ITE/ Start of Turbo-Pumps | 0.5d | 2015-12-01 13:00 | 2015-12-01 17:00 | 38 |  |  | 3d |  | start no earlier than 2015-12-01 08:00 | D.Wang | 4h |  |
| 40 | 4.12 | Sheilding Blocks Transfer -ITW to ITE | 1d | 2015-12-07 08:00 | 2015-12-07 17:00 | 39 |  |  | 0d |  | start no earlier than 2015-12-07 08:00 | D.Wang | 8h |  |
| 41 | 5 | **TM3 Evaluation at CS** | 8d | 2015-11-05 08:00 A | 2015-11-16 17:00 |  | 87% | 1.03d | 15d |  |  |  | 128h | 112h |
| 42 | 5.1 | Module Move-TM3 - Silo to CS | 1d | 2015-11-05 08:00 A | 2015-11-06 17:00 A |  | 100% |  |  |  | finish no earlier than 2015-11-06 17:00 | D.Wang; T.Cave | 16h | 16h |
| 43 | 5.2 | TM3 TP2 Replacement, Opened panel o-rings Replacement | 0.25d | 2015-11-06 08:00 A | 2015-11-06 10:00 A | 42 | 100% |  |  |  | start no earlier than 2015-11-16 08:00 | D.Wang; A. Laxdal | 4h | 4h |
| 44 | 5.3 | Start of TM3 Vacuum Pumps at CS | 0.5d | 2015-11-06 08:00 A | 2015-11-06 12:00 A | 43 | 100% |  |  |  | start no earlier than 2015-11-16 08:00 | D.Wang; A.Mjos | 8h | 8h |
| 45 | 5.4 | Leak Check/Helium Pressure, Air to Vacuum | 0.5d | 2015-11-09 08:00 A | 2015-11-09 12:00 A | 44 | 100% |  |  |  | start no earlier than 2015-11-17 08:00 | A. Laxdal; D.Wang; A.Mjos | 12h | 12h |
| 46 | 5.5 | High Current Cables Installation/Start of CS Water Pumps | 0.5d | 2015-11-09 08:00 A | 2015-11-09 12:00 A | 45 | 100% |  |  |  | start no earlier than 2015-11-17 08:00 | D.Wang; A. Laxdal | 8h | 8h |
| 47 | 5.6 | HV and other TM3 tests | 4d | 2015-11-10 08:00 A | 2015-11-13 17:00 A | 46 | 100% |  |  |  | finish no earlier than 2015-11-13 17:00 | A.Mjos; A. Laxdal | 64h | 64h |
| 48 | 5.7 | Module Move -TM3 - CS to Silo | 1d | 2015-11-16 08:00 | 2015-11-16 17:00 | 47 |  |  | 15d |  | start no earlier than 2015-11-16 08:00 | D.Wang; T.Cave | 16h |  |
| 49 | 6 | **SHC clean up** | 3d | 2015-11-17 08:00 | 2015-11-19 17:00 |  |  |  | 12d |  |  |  | 48h |  |
| 50 | 6.1 | Final Preparations for Cell Entry/Drum Waste Removal | 1d | 2015-11-17 08:00 | 2015-11-17 17:00 |  |  |  | 12d | 0d | start no earlier than 2015-11-17 08:00 | C.Fisher; D.Wang | 16h |  |
| 51 | 6.2 | Drum Lower into Hot Cell/ Cell Entry | 0.5d | 2015-11-18 08:00 | 2015-11-18 12:00 | 50 |  |  | 12d | 0d | start no earlier than 2015-11-18 08:00 | D.Wang; C.Fisher | 8h |  |
| 52 | 6.3 | Drum Filled with Waste / Crane out of Cell to B2 by Vault | 0.5d | 2015-11-18 13:00 | 2015-11-18 17:00 | 51 |  |  | 12d | 0d | start no earlier than 2015-11-18 08:00 | C.Fisher; D.Wang | 8h |  |
| 53 | 6.4 | RPG Swipe Drum/ Drum Lowered into North Hot Cell | 1d | 2015-11-19 08:00 | 2015-11-19 17:00 | 52 |  |  | 12d |  | start no earlier than 2015-11-19 08:00 | RPG; D.Wang | 16h |  |
